# Мярка 6-3-D-007

Schedule from MS Project, 2017-02-06 to 2017-02-27.

## Calendars

- Standard: Mon-Fri 08:00-12:00, 13:00-17:00; Sat-Sun off.

## Schedule

| ID | WBS | Task | Duration | Start | Finish | Predecessors | Total slack | Text1 |
| --- | --- | --- | --- | --- | --- | --- | --- | --- |
| 1 | 1 | **Усилване или подмяна с нови на прерязани стоманени греди** | 16d | 2017-02-06 | 2017-02-27 |  | 0d | 16 дни |
| 2 | 1.1 | Започване на подготовка на строителна площадка - запознаване със схемата на СМР. Установяване на мястото на монтаж на всеки от новите стоманени елементи | 2d | 2017-02-06 | 2017-02-07 |  | 0d | 2 дни |
| 3 | 1.2 | Монтаж на скеле | 2d | 2017-02-08 | 2017-02-09 | 2 | 0d | 2 дни |
| 4 | 1.3 | Почистване на повърхностите на метални пръти и заварки. Отстраняването на старото антикорозионно покритие, ръжда, масла и други замърсявания до основен метал | 3d | 2017-02-10 | 2017-02-14 | 3 | 0d | 3 дни |
| 5 | 1.4 | Преди започване на огневи работи, обстойна проверка на всички размери указани на работния чертеж - СК | 1d | 2017-02-15 | 2017-02-15 | 4 | 0d | 1 ден |
| 6 | 1.5 | Изпълнение на заваръчните дейности | 3d | 2017-02-16 | 2017-02-20 | 5 | 0d | 3 дни |
| 7 | 1.6 | Оглед и изпитване на заваръчните шевове, преди полагане на антикорозонна защита | 1d | 2017-02-21 | 2017-02-21 | 6 | 0d | 1 ден |
| 8 | 1.7 | Полагане на антикорозонна защита | 2d | 2017-02-22 | 2017-02-23 | 7 | 0d | 2 дни |
| 9 | 1.8 | Изчистване на зоните от работната площадка от строителни отпадъци, демонтаж на крепителни елементи, строително скеле, и предпазните огнеупорни материали на тръбопроводите | 2d | 2017-02-24 | 2017-02-27 | 8 | 0d | 2 дни |
